# calice2

Schedule from MS Project, 2003-10-24 to 2003-12-12.
CCLRC

## Calendars

- Standard: Mon-Fri 08:00-12:00, 13:00-17:00; Sat-Sun off.

## Schedule

| ID | WBS | Task | Type | Duration | Start | Finish | Predecessors | Total slack | Constraint | Deadline |
| --- | --- | --- | --- | --- | --- | --- | --- | --- | --- | --- |
| 1 | 1 | **Board Manufacture** |  | 16d | 2003-10-24 | 2003-11-14 |  | 0d |  |  |
| 2 | 1.1 | pcb tape out | milestone | 0d | 2003-10-24 | 2003-10-24 |  | 0d | start no earlier than 2003-10-24 |  |
| 3 | 1.2 | pcb manufacture |  | 10d | 2003-10-24 | 2003-11-06 | 2 | 0d |  |  |
| 4 | 1.3 | 2 0ff pcb manufactured | milestone | 0d | 2003-11-06 | 2003-11-06 | 3 | 0d |  |  |
| 5 | 1.4 | ship to ral |  | 0.5d | 2003-11-07 | 2003-11-07 | 4 | 0d |  |  |
| 6 | 1.5 | inspectection |  | 0.5d | 2003-11-07 | 2003-11-07 | 5 | 0d |  |  |
| 7 | 1.6 | ship to assembly company |  | 0.5d | 2003-11-10 | 2003-11-10 | 6 | 0d |  |  |
| 8 | 1.7 | pcb at assembly company | milestone | 0d | 2003-11-10 | 2003-11-10 | 7 | 0d |  |  |
| 9 | 1.8 | pcb assembly |  | 1d | 2003-11-10 | 2003-11-11 | 8 | 0d |  |  |
| 10 | 1.9 | pcb assembly complete |  | 3d | 2003-11-11 | 2003-11-14 | 9 | 0d |  |  |
| 11 | 1.10 | pcb shipment |  | 0.5d | 2003-11-14 | 2003-11-14 | 10 | 0d |  |  |
| 12 | 1.11 | assembled pcb at ral | milestone | 0d | 2003-11-14 | 2003-11-14 | 11 | 0d |  |  |
| 13 | 2 | **Initial Tests** |  | 5d | 2003-11-17 | 2003-11-21 |  | 0d |  |  |
| 14 | 2.1 | Visual Inspection |  | 0.25d | 2003-11-17 | 2003-11-17 | 12 | 0d |  |  |
| 15 | 2.2 | Power up test |  | 0.5d | 2003-11-17 | 2003-11-17 | 14 | 0d |  |  |
| 16 | 2.3 | JTAG |  | 0.25d | 2003-11-17 | 2003-11-17 | 15 | 0d |  |  |
| 17 | 2.4 | Contingency |  | 4d | 2003-11-18 | 2003-11-21 | 16, 25 | 0d |  |  |
| 18 | 2.5 | module ready for fpga development | milestone | 0d | 2003-11-21 | 2003-11-21 | 17 | 0d |  |  |
| 19 | 3 | **VFE Test Work** |  | 15d | 2003-11-24 | 2003-12-12 |  | 0d |  |  |
| 20 | 3.1 | Serial DAQ Development |  | 10d | 2003-11-24 | 2003-12-05 | 18 | 0d |  |  |
| 21 | 3.2 | ready for VFE tests | milestone | 0d | 2003-12-05 | 2003-12-05 | 20 | 0d |  |  |
| 22 | 3.3 | VFE Tests |  | 5d | 2003-12-08 | 2003-12-12 | 21 | 0d |  |  |
| 23 | 3.4 | VFE Test complete | milestone | 0d | 2003-12-12 | 2003-12-12 | 22 | 0d |  | 2004-01-05 |
| 24 | 4 | **FPGA Design** |  | 10d | 2003-11-03 | 2003-11-14 |  | 0d |  |  |
| 25 | 4.1 | Serial DAQ FPGA Design |  | 10d | 2003-11-03 | 2003-11-14 |  | 0d | must finish on 2003-11-14 |  |

| ID | WBS | Task | Type | Duration | Start | Finish | Predecessors | Total slack | Free slack | Constraint | Deadline |
| --- | --- | --- | --- | --- | --- | --- | --- | --- | --- | --- | --- |
| 26 | 5 | **ADC Testing** |  | 5d | 2003-12-08 | 2003-12-12 |  | 0d |  |  |  |
| 27 | 5.1 | ADC Performance testing |  | 5d | 2003-12-08 | 2003-12-12 | 20 | 0d |  |  |  |
| 28 | 5.2 | Basic ADC performance tests complete | milestone | 0d | 2003-12-12 | 2003-12-12 | 27 | 0d |  |  |  |
| 29 | 6 | **Final FPGA design** |  | 20d | 2003-11-06 | 2003-12-03 |  | 0d |  |  |  |
| 30 | 6.1 | final firmware development start | milestone | 0d | 2003-11-06 | 2003-11-06 |  | 0d |  | must start on 2003-11-06 |  |
| 31 | 6.2 | Final FE FPGA Design |  | 10d | 2003-11-06 | 2003-11-19 | 30 | 7d | 0d |  |  |
| 32 | 6.3 | BE FPGA Trigger Logic Design |  | 10d | 2003-11-06 | 2003-11-19 | 30 | 7d | 0d |  |  |
| 33 | 6.4 | Final FE-BE FPGA Integration |  | 10d | 2003-11-20 | 2003-12-03 | 32, 31 | 7d | 0d |  |  |
| 34 | 6.5 | FE-BE FPGA Integration Complete | milestone | 0d | 2003-12-03 | 2003-12-03 | 33 | 7d |  |  | 2004-01-12 |
